# ESMCP_Programme Plan v007_new

Schedule from MS Project, 2014-01-01 to 2014-03-04, status date 2012-10-12.
NPIA

## Calendars

- Standard: Mon-Fri 08:00-12:00, 13:00-17:00; Sat-Sun off. Exceptions (off unless hours are given): 2012-12-25 to 2020-12-25 (Christmas, recurring), 2012-12-26 to 2020-12-26 (Boxing Day, recurring).

## Resources

| Resource |
| --- |
| T Res |
| A Non |
| A Sca |

## Schedule

| ID | WBS | Task | Type | Duration | Start | Finish | Predecessors | Total slack | Schedule Indicator |
| --- | --- | --- | --- | --- | --- | --- | --- | --- | --- |
| 1 | 1 | **[Project Name] - Project Communication Plan** |  | 45d? | 2014-01-01 | 2014-03-04 |  | 0d | No baseline |
| 2 | 1.1 | **Key Milestones** |  | 45d? | 2014-01-01 | 2014-03-04 |  | 0d | No baseline |
| 3 | 1.1.1 | Case for Change Complete | milestone | 0d | 2014-01-03 | 2014-01-03 | 20 | 42d | No baseline |
| 4 | 1.1.2 | Key Stakeholder / Communications Needs Matrix Complete |  | 1d? | 2014-01-10 | 2014-01-10 | 25 | 37d | No baseline |
| 5 | 1.1.3 | Communications materials (posters, videos etc) Complete |  | 1d? | 2014-01-01 | 2014-01-01 |  | 50d | No baseline |
| 6 | 1.1.4 | Key Communication Messages Complete |  | 1d? | 2014-01-16 | 2014-01-16 | 31 | 33d | No baseline |
| 7 | 1.1.5 | High level Briefing document Complete |  | 1d? | 2014-01-21 | 2014-01-21 | 37 | 30d | No baseline |
| 8 | 1.1.6 | High Level Communication Plan Complete |  | 1d? | 2014-01-24 | 2014-01-24 | 42 | 27d | No baseline |
| 9 | 1.1.7 | Detailed Communication Plan Complete |  | 1d? | 2014-01-29 | 2014-01-29 | 47 | 24d | No baseline |
| 10 | 1.1.8 | Project Communications Complete |  | 1d? | 2014-02-11 | 2014-02-11 | 52 | 15d | No baseline |
| 11 | 1.1.9 | Countdown Communications Complete |  | 1d? | 2014-02-24 | 2014-02-24 | 63 | 6d | No baseline |
| 12 | 1.1.10 | Post Go Live Communications Complete |  | 1d? | 2014-03-04 | 2014-03-04 | 74 | 0d | No baseline |
| 13 | 1.2 | Communication Plan complete |  | 1d? | 2014-01-01 | 2014-01-01 |  | 4d | No baseline |
| 14 | 1.3 | **Dependencies** |  | 0d | 2014-01-01 | 2014-01-01 |  | 45d | No baseline |
| 15 | 1.3.1 | **Inbound** |  | 0d | 2014-01-01 | 2014-01-01 |  | 45d | No baseline |
| 16 | 1.3.1.1 | IN: EXT: Example External Dependency | milestone | 0d | 2014-01-01 | 2014-01-01 |  | 21d | No baseline |
| 17 | 1.3.2 | **Outbound** |  | 0d | 2014-01-01 | 2014-01-01 |  | 45d | No baseline |
| 18 | 1.3.2.1 | OUT: Example Outbound Dependency | milestone | 0d | 2014-01-01 | 2014-01-01 |  | 21d | No baseline |
| 19 | 1.4 | **Communications Workstream** |  | 44d | 2014-01-01 | 2014-03-03 |  | 0d | No baseline |
| 20 | 1.4.1 | **Case for Change Complete** |  | 3d | 2014-01-01 | 2014-01-03 |  | 0d | No baseline |
| 21 | 1.4.1.1 | Draft Case for Change |  | 1d | 2014-01-01 | 2014-01-01 |  | 0d | No baseline |
| 22 | 1.4.1.2 | Review Case for Change |  | 1d | 2014-01-02 | 2014-01-02 | 21 | 0d | No baseline |
| 23 | 1.4.1.3 | Approve Case for Change |  | 1d | 2014-01-03 | 2014-01-03 | 22 | 0d | No baseline |
| 24 | 1.4.1.4 | Complete Case for Change | milestone | 0d | 2014-01-03 | 2014-01-03 | 23 | 0d | No baseline |

Notes:
- 1: This Communications Plan Template should be used for recording the activities requiring completion during and after the project. It does not include all communication activities that a project might need to complete during its lifecycle. / The project should define its own communication activities and adapt this Template to their needs.

| ID | WBS | Task | Type | Duration | Start | Finish | Predecessors | Total slack | Schedule Indicator |
| --- | --- | --- | --- | --- | --- | --- | --- | --- | --- |
| 25 | 1.4.2 | **Key Stakeholder / Communications Needs Matrix Complete** |  | 4d | 2014-01-06 | 2014-01-09 | 20 | 0d | No baseline |
| 26 | 1.4.2.1 | Analyse key Stakeholder / Communications needs Matrix |  | 1d | 2014-01-06 | 2014-01-06 |  | 0d | No baseline |
| 27 | 1.4.2.2 | Draft key Stakeholder / Communications needs Matrix |  | 1d | 2014-01-07 | 2014-01-07 | 26 | 0d | No baseline |
| 28 | 1.4.2.3 | Review key Stakeholder / Communications needs Matrix |  | 1d | 2014-01-08 | 2014-01-08 | 27 | 0d | No baseline |
| 29 | 1.4.2.4 | Approve key Stakeholder / Communications needs Matrix |  | 1d | 2014-01-09 | 2014-01-09 | 28 | 0d | No baseline |
| 30 | 1.4.2.5 | Complete Key Stakeholder / Communications Needs Matrix | milestone | 0d | 2014-01-09 | 2014-01-09 | 29 | 0d | No baseline |
| 31 | 1.4.3 | **Key Communication Messages Complete** |  | 4d | 2014-01-10 | 2014-01-15 | 25 | 0d | No baseline |
| 32 | 1.4.3.1 | Analyse key Communication messages |  | 1d | 2014-01-10 | 2014-01-10 |  | 0d | No baseline |
| 33 | 1.4.3.2 | Draft key Communication Messages |  | 1d | 2014-01-13 | 2014-01-13 | 32 | 0d | No baseline |
| 34 | 1.4.3.3 | Review key Communication Messages |  | 1d | 2014-01-14 | 2014-01-14 | 33 | 0d | No baseline |
| 35 | 1.4.3.4 | Approve key Communication Messages |  | 1d | 2014-01-15 | 2014-01-15 | 34 | 0d | No baseline |
| 36 | 1.4.3.5 | Complete Key Communication Messages | milestone | 0d | 2014-01-15 | 2014-01-15 | 35 | 0d | No baseline |
| 37 | 1.4.4 | **High level Briefing Document Complete** |  | 3d | 2014-01-16 | 2014-01-20 | 31 | 0d | No baseline |
| 38 | 1.4.4.1 | Draft high level Briefing document |  | 1d | 2014-01-16 | 2014-01-16 |  | 0d | No baseline |
| 39 | 1.4.4.2 | Review high level Briefing document |  | 1d | 2014-01-17 | 2014-01-17 | 38 | 0d | No baseline |
| 40 | 1.4.4.3 | Approve high level Briefing document |  | 1d | 2014-01-20 | 2014-01-20 | 39 | 0d | No baseline |
| 41 | 1.4.4.4 | Complete High level Briefing document | milestone | 0d | 2014-01-20 | 2014-01-20 | 40 | 0d | No baseline |
| 42 | 1.4.5 | **High Level Communications Plan Complete** |  | 3d | 2014-01-21 | 2014-01-23 | 37 | 0d | No baseline |
| 43 | 1.4.5.1 | Draft high level Communications Plan |  | 1d | 2014-01-21 | 2014-01-21 |  | 0d | No baseline |
| 44 | 1.4.5.2 | Review high level Communications Plan |  | 1d | 2014-01-22 | 2014-01-22 | 43 | 0d | No baseline |
| 45 | 1.4.5.3 | Approve high level Communications Plan |  | 1d | 2014-01-23 | 2014-01-23 | 44 | 0d | No baseline |
| 46 | 1.4.5.4 | Complete High level Communications Plan | milestone | 0d | 2014-01-23 | 2014-01-23 | 45 | 0d | No baseline |
| 47 | 1.4.6 | **Detailed Communications Plan Complete** |  | 3d | 2014-01-24 | 2014-01-28 | 42 | 0d | No baseline |
| 48 | 1.4.6.1 | Draft detailed Communications Plan |  | 1d | 2014-01-24 | 2014-01-24 |  | 0d | No baseline |
| 49 | 1.4.6.2 | Review detailed Communications Plan |  | 1d | 2014-01-27 | 2014-01-27 | 48 | 0d | No baseline |
| 50 | 1.4.6.3 | Approve detailed Communications Plan |  | 1d | 2014-01-28 | 2014-01-28 | 49 | 0d | No baseline |
| 51 | 1.4.6.4 | Complete Detailed Communications Plan | milestone | 0d | 2014-01-28 | 2014-01-28 | 50 | 0d | No baseline |

| ID | WBS | Task | Type | Duration | Start | Finish | Predecessors | Total slack | Schedule Indicator |
| --- | --- | --- | --- | --- | --- | --- | --- | --- | --- |
| 52 | 1.4.7 | **Project Communications Complete** |  | 9d | 2014-01-29 | 2014-02-10 | 47 | 0d | No baseline |
| 53 | 1.4.7.1 | Draft and Review Phase 1 Communications |  | 1d | 2014-01-29 | 2014-01-29 |  | 0d | No baseline |
| 54 | 1.4.7.2 | Approve Phase 1 Communications |  | 1d | 2014-01-30 | 2014-01-30 | 53 | 0d | No baseline |
| 55 | 1.4.7.3 | Deliever Phase 1 Communcations (project to define tasks...) |  | 1d | 2014-01-31 | 2014-01-31 | 54 | 0d | No baseline |
| 56 | 1.4.7.4 | Draft and Review Phase 2 Communications |  | 1d | 2014-02-03 | 2014-02-03 | 55 | 0d | No baseline |
| 57 | 1.4.7.5 | Approve Phase 2 Communications |  | 1d | 2014-02-04 | 2014-02-04 | 56 | 0d | No baseline |
| 58 | 1.4.7.6 | Deliever Phase 2 Communcations (project to define tasks...) |  | 1d | 2014-02-05 | 2014-02-05 | 57 | 0d | No baseline |
| 59 | 1.4.7.7 | Draft and Review Phase 3 Communications |  | 1d | 2014-02-06 | 2014-02-06 | 58 | 0d | No baseline |
| 60 | 1.4.7.8 | Approve Phase 3 Communications |  | 1d | 2014-02-07 | 2014-02-07 | 59 | 0d | No baseline |
| 61 | 1.4.7.9 | Deliever Phase 3 Communcations (project to define tasks...) |  | 1d | 2014-02-10 | 2014-02-10 | 60 | 0d | No baseline |
| 62 | 1.4.7.10 | Project Communications Complete | milestone | 0d | 2014-02-10 | 2014-02-10 | 61 | 0d | No baseline |
| 63 | 1.4.8 | **Countdown Communications Complete** |  | 9d | 2014-02-11 | 2014-02-21 | 52 | 0d | No baseline |
| 64 | 1.4.8.1 | Draft and Review Countdown 1 Communications |  | 1d | 2014-02-11 | 2014-02-11 |  | 0d | No baseline |
| 65 | 1.4.8.2 | Approve Countdown 1 Communications |  | 1d | 2014-02-12 | 2014-02-12 | 64 | 0d | No baseline |
| 66 | 1.4.8.3 | Deliver Countdown 1 Communications |  | 1d | 2014-02-13 | 2014-02-13 | 65 | 0d | No baseline |
| 67 | 1.4.8.4 | Draft and Review Countdown 2 Communications |  | 1d | 2014-02-14 | 2014-02-14 | 66 | 0d | No baseline |
| 68 | 1.4.8.5 | Approve Countdown 2 Communications |  | 1d | 2014-02-17 | 2014-02-17 | 67 | 0d | No baseline |
| 69 | 1.4.8.6 | Deliver Countdown 2 Communications |  | 1d | 2014-02-18 | 2014-02-18 | 68 | 0d | No baseline |
| 70 | 1.4.8.7 | Draft and Review Countdown 3 Communications |  | 1d | 2014-02-19 | 2014-02-19 | 69 | 0d | No baseline |
| 71 | 1.4.8.8 | Approve Countdown 3 Communications |  | 1d | 2014-02-20 | 2014-02-20 | 70 | 0d | No baseline |
| 72 | 1.4.8.9 | Deliver Countdown 3 Communications |  | 1d | 2014-02-21 | 2014-02-21 | 71 | 0d | No baseline |
| 73 | 1.4.8.10 | Countdown Communications Complete | milestone | 0d | 2014-02-21 | 2014-02-21 | 72 | 0d | No baseline |
| 74 | 1.4.9 | **Post Go Live Communications Complete** |  | 6d | 2014-02-24 | 2014-03-03 | 63 | 0d | No baseline |
| 75 | 1.4.9.1 | Draft and Review Go Live (Day 0-7) Communications |  | 1d | 2014-02-24 | 2014-02-24 |  | 0d | No baseline |
| 76 | 1.4.9.2 | Approve Go Live (Day 0-7) Communications |  | 1d | 2014-02-25 | 2014-02-25 | 75 | 0d | No baseline |
| 77 | 1.4.9.3 | Deliver Go Live (Day 0-7) Communcations |  | 1d | 2014-02-26 | 2014-02-26 | 76 | 0d | No baseline |
| 78 | 1.4.9.4 | Draft and Review Post Go Live (Week 3-6) Communications |  | 1d | 2014-02-27 | 2014-02-27 | 77 | 0d | No baseline |
| 79 | 1.4.9.5 | Approve Post Go Live (Week 3-6) Communications |  | 1d | 2014-02-28 | 2014-02-28 | 78 | 0d | No baseline |
| 80 | 1.4.9.6 | Deliver Post Go Live (Week 3-6) Communcations |  | 1d | 2014-03-03 | 2014-03-03 | 79 | 0d | No baseline |
| 81 | 1.4.9.7 | Post Go Live Communications Complete | milestone | 0d | 2014-03-03 | 2014-03-03 | 80 | 0d | No baseline |
